# Planificación TFG Héctor Pablos

Schedule from MS Project, 2014-03-05 to 2014-07-11, 2 hours a day.

## Calendars

- TFGHéctorPablos: Mon 09:00-13:00, 15:00-19:00; Tue off; Wed 09:00-13:00, 15:00-19:00; Thu off; Fri 09:00-13:00, 15:00-19:00; Sat-Sun off.

## Resources

| Resource | Group |
| --- | --- |
| Héctor Pablos López | Alumno |
| Carlos Enrique Vivaracho Pascual | Tutor |

## Schedule

| ID | WBS | Task | Type | Duration | Start | Finish | Predecessors | Total slack | Free slack | Constraint | Resources | Work |
| --- | --- | --- | --- | --- | --- | --- | --- | --- | --- | --- | --- | --- |
| 1 | 1 | **Plan de desarrollo del proyecto** |  | 24d | 2014-03-05 09:00 | 2014-03-17 19:00 |  | 52.5d |  |  |  | 33h |
| 2 | 1.1 | Redacción de la documentación |  | 40h | 2014-03-05 09:00 | 2014-03-14 19:00 | 3SS | 201.5d | 1.5d | start no earlier than 2013-12-16 19:00 |  |  |
| 3 | 1.2 | Determinar el alcance |  | 2h | 2014-03-05 09:00 | 2014-03-05 11:00 |  | 52.5d | 0d |  | Carlos Enrique Vivaracho Pascual; Héctor Pablos López | 4h |
| 4 | 1.3 | **Planificación** |  | 10.5d | 2014-03-05 11:00 | 2014-03-10 18:00 |  | 200d | 0d |  |  |  |
| 5 | 1.3.1 | Definición de actividades |  | 6h | 2014-03-05 11:00 | 2014-03-05 19:00 | 3 | 200d | 0d |  |  |  |
| 6 | 1.3.2 | Secuenciación de actividades |  | 4h | 2014-03-07 09:00 | 2014-03-07 13:00 | 5 | 200d | 0d |  |  |  |
| 7 | 1.3.3 | Definir recursos preliminares |  | 4h | 2014-03-07 15:00 | 2014-03-07 19:00 | 6 | 200d | 0d |  |  |  |
| 8 | 1.3.4 | Estimación de duración |  | 3h | 2014-03-10 09:00 | 2014-03-10 12:00 | 7 | 200d | 0d |  |  |  |
| 9 | 1.3.5 | Afianzar Recursos |  | 4h | 2014-03-10 12:00 | 2014-03-10 18:00 | 8 | 200d |  |  |  |  |
| 10 | 1.4 | Estimación de costes |  | 5h | 2014-03-12 15:00 | 2014-03-14 10:00 | 4FS+5h | 200d | 0d |  | Héctor Pablos López | 5h |
| 11 | 1.5 | Plan de control del proyecto |  | 5h | 2014-03-14 10:00 | 2014-03-14 17:00 | 10 | 200d | 0d |  | Héctor Pablos López | 5h |
| 12 | 1.6 | Plan de gestión de configuraciones |  | 5h | 2014-03-14 17:00 | 2014-03-17 12:00 | 11 | 200d | 0d |  | Héctor Pablos López | 5h |
| 13 | 1.7 | Identificación y análisis de riesgos |  | 9h | 2014-03-05 11:00 | 2014-03-07 12:00 | 3 | 52.5d | 0d |  | Héctor Pablos López | 9h |
| 14 | 1.8 | Auditoría |  | 5h | 2014-03-17 12:00 | 2014-03-17 19:00 | 12, 2, 13 | 200d | 0d |  | Héctor Pablos López | 5h |
| 15 | 1.9 | Artefacto: Plan de desarrollo | milestone | 0h | 2014-03-17 19:00 | 2014-03-17 19:00 | 14 | 200d |  |  |  |  |
| 16 | 2 | **Análisis** |  | 27.5d | 2014-03-07 12:00 | 2014-03-24 11:00 |  | 52.5d |  |  |  | 131h |
| 17 | 2.1 | Redacción de la documentación de análisis |  | 50h | 2014-03-07 12:00 | 2014-03-21 16:00 | 18SS | 52.5d | 0d |  |  |  |
| 18 | 2.2 | Identificación de stakeholders |  | 3h | 2014-03-07 12:00 | 2014-03-07 17:00 | 13 | 52.5d | 0d |  | Héctor Pablos López | 3h |
| 19 | 2.3 | Búsqueda y análisis de documentación |  | 2h | 2014-03-07 17:00 | 2014-03-07 19:00 | 18 | 75d | 22.5d |  | Héctor Pablos López | 2h |
| 20 | 2.4 | Investigación del estado del arte |  | 40h | 2014-03-07 12:00 | 2014-03-19 12:00 | 13 | 198.5d |  |  | Carlos Enrique Vivaracho Pascual; Héctor Pablos López | 80h |
| 21 | 2.5 | **Análisis de requisitos** |  | 5.5d | 2014-03-10 09:00 | 2014-03-12 12:00 |  | 52.5d | 0d |  |  | 11h |
| 22 | 2.5.1 | Requisitos de usuario |  | 2h | 2014-03-10 09:00 | 2014-03-10 11:00 | 13FS+5h | 52.5d | 0d |  | Héctor Pablos López | 2h |
| 23 | 2.5.2 | Requisitos funcionales |  | 5h | 2014-03-10 11:00 | 2014-03-10 18:00 | 22 | 54.5d |  |  | Héctor Pablos López | 5h |
| 24 | 2.5.3 | Requisitos no funcionales |  | 3h | 2014-03-10 18:00 | 2014-03-12 11:00 | 22FS+5h | 53d |  |  | Héctor Pablos López | 3h |
| 25 | 2.5.4 | Requisitos de información |  | 1h | 2014-03-12 11:00 | 2014-03-12 12:00 | 22FS+8h | 52.5d |  |  | Héctor Pablos López | 1h |

Notes:
- 2: Descripción: Elaboración de la documentación referente al plan de desarrollo del proyecto
- 3: Descripción: Determinación del alcance y los límites
- 5: Descripción: Identificación y descripción de las actividades necesarias para llevar a cabo el proyecto
- 6: Descripción: Establecer la relación entre las diferentes actividades
- 7: Descripción: Definir los recursos de los que disponemos (temporales, materiales, recursos humanos)
- 8: Descripción: Determinación del tiempo en el que se puede llevar a cabo cada tarea
- 9: Descripción: Asignación de los recursos a cada actividad
- 10: Text1: Cálculo de los costes que supondrá la elaboración del proyecto / Descripción: Cálculo de los costes que supondrá la elaboración del proyecto
- 11: Text1: Elaboración del plan que se va a seguir para controlar que el proyecto se desarrolla correctamente / Descripción: Elaboración del plan que se va a seguir para controlar que el proyecto se desarrolla correctamente
- 12: Text1: Creación del plan correspondiente para la gestión de configuraciones / Descripción: Creación del plan correspondiente para la gestión de configuraciones
- 13: Text1: Describir los riesgos a los que nos podemos enfrentar, sus posibles consecuencias y cómo enfrentarles / Descripción: Describir los riesgos a los que nos podemos enfrentar, sus posibles consecuencias y cómo enfrentarles
- 14: Text1: Supervisión y aprobación del plan de desarrollo del proyecto / Descripción: Supervisión y aprobación del plan de desarrollo del proyecto
- 17: Descripción: Elaboración de la documentación referente al análisis de la aplicación
- 18: Descripción: Identificar, describir e identificar las necesidades de los stakeholders del sistema
- 19: Descripción: Recopilación de información para afrontar el proyecto teniendo en cuenta las necesidades de los stakeholders
- 20: Descripción: Recopilación de información sobre los diferentes métodos para la verificación de locutor y las herramientas disponibles para realizarlo
- 22: Descripción: Identificación y descripción de los requisitos de usuario
- 23: Descripción: Identificación y descripción de los requisitos funcionales
- 24: Descripción: Identificación y descripción de los requisitos no funcionales
- 25: Descripción: Identificación y descripción de los requisitos de información

| ID | WBS | Task | Type | Duration | Start | Finish | Predecessors | Total slack | Free slack | Constraint | Resources | Work |
| --- | --- | --- | --- | --- | --- | --- | --- | --- | --- | --- | --- | --- |
| 26 | 2.6 | **Análisis de casos de uso** |  | 17d | 2014-03-12 12:00 | 2014-03-21 16:00 |  | 52.5d | 0d |  |  | 30h |
| 27 | 2.6.1 | Identificación y realización de casos de uso |  | 15h | 2014-03-12 12:00 | 2014-03-17 11:00 | 21 | 52.5d | 0d | start no earlier than 2014-01-20 19:00 | Héctor Pablos López | 15h |
| 28 | 2.6.2 | Matriz de trazabilidad |  | 2h | 2014-03-17 11:00 | 2014-03-17 13:00 | 27 | 61d |  |  | Héctor Pablos López | 2h |
| 29 | 2.6.3 | Modelo de dominio |  | 5h | 2014-03-19 09:00 | 2014-03-19 16:00 | 27FS+6h | 52.5d | 0d |  | Héctor Pablos López | 5h |
| 30 | 2.6.4 | Diagramas de secuencia |  | 8h | 2014-03-19 16:00 | 2014-03-21 16:00 | 29 | 52.5d |  |  | Héctor Pablos López | 8h |
| 31 | 2.7 | Auditoría |  | 5h | 2014-03-21 16:00 | 2014-03-24 11:00 | 17, 19, 26 | 52.5d | 0d |  | Héctor Pablos López | 5h |
| 32 | 2.8 | Artefacto: Documento de análisis | milestone | 0h | 2014-03-24 11:00 | 2014-03-24 11:00 | 31 | 191d |  |  |  |  |
| 33 | 3 | **Diseño** |  | 35.5d | 2014-03-24 11:00 | 2014-04-14 10:00 |  | 52.5d |  |  |  | 71h |
| 34 | 3.1 | Realización de documentación |  | 60h | 2014-03-24 11:00 | 2014-04-09 17:00 | 36SS | 158.5d | 3d |  |  |  |
| 35 | 3.2 | **Descripción de la arquitectura** |  | 7d | 2014-03-24 11:00 | 2014-03-26 19:00 |  | 52.5d | 0d |  |  | 14h |
| 36 | 3.2.1 | Identificación de la tecnología |  | 5h | 2014-03-24 11:00 | 2014-03-24 18:00 | 31 | 52.5d | 0d |  | Héctor Pablos López | 5h |
| 37 | 3.2.2 | Identificación de interfaces |  | 3h | 2014-03-24 18:00 | 2014-03-26 11:00 | 36 | 52.5d | 0d |  | Héctor Pablos López | 3h |
| 38 | 3.2.3 | Realización de diagramas |  | 6h | 2014-03-26 11:00 | 2014-03-26 19:00 | 37 | 52.5d | 0d |  | Héctor Pablos López | 6h |
| 39 | 3.3 | **Diseño de la arquitectura** |  | 6d | 2014-03-28 09:00 | 2014-03-31 13:00 |  | 52.5d | 0d |  |  | 12h |
| 40 | 3.3.1 | Descomposición en subsistemas |  | 4h | 2014-03-28 09:00 | 2014-03-28 13:00 | 35 | 52.5d | 0d |  | Héctor Pablos López | 4h |
| 41 | 3.3.2 | Topología del sistema |  | 1h | 2014-03-28 15:00 | 2014-03-28 16:00 | 40 | 52.5d | 0d |  | Héctor Pablos López | 1h |
| 42 | 3.3.3 | Gestión de la persistencia |  | 4h | 2014-03-28 16:00 | 2014-03-31 10:00 | 38FS+5h | 54d |  |  | Héctor Pablos López | 4h |
| 43 | 3.3.4 | Vista lógica del sistema |  | 3h | 2014-03-31 10:00 | 2014-03-31 13:00 | 36, 41FS+4h | 52.5d |  |  | Héctor Pablos López | 3h |
| 44 | 3.4 | Casos de uso de diseño |  | 15h | 2014-03-31 15:00 | 2014-04-04 12:00 | 27, 39 | 52.5d | 0d |  | Héctor Pablos López | 15h |
| 45 | 3.5 | Diagramas de secuencia de diseño |  | 15h | 2014-04-04 12:00 | 2014-04-09 11:00 | 44 | 52.5d | 0d |  | Héctor Pablos López | 15h |
| 46 | 3.6 | Modelo de dominio de diseño |  | 10h | 2014-04-09 11:00 | 2014-04-11 13:00 | 45 | 52.5d | 0d |  | Héctor Pablos López | 10h |
| 47 | 3.7 | Auditoría |  | 5h | 2014-04-11 15:00 | 2014-04-14 10:00 | 46, 34 | 155.5d | 0d |  | Héctor Pablos López | 5h |
| 48 | 3.8 | Artefacto: Documento de diseño | milestone | 0h | 2014-04-14 10:00 | 2014-04-14 10:00 | 47 | 155.5d |  |  | Héctor Pablos López |  |
| 49 | 4 | **Implementación** |  | 47.5d | 2014-04-14 11:00 | 2014-05-12 10:00 |  | 52.5d |  |  |  | 135h |
| 50 | 4.1 | Desarrollo del código |  | 80h | 2014-04-14 11:00 | 2014-05-07 11:00 | 46FS+6h | 52.5d | 0d |  | Héctor Pablos López | 80h |
| 51 | 4.2 | Pruebas de los programadores (60%) |  | 40h | 2014-04-18 11:00 | 2014-04-30 11:00 | 50FS-8% | 64.5d | 12d |  | Héctor Pablos López | 40h |
| 52 | 4.3 | Integración de módulos |  | 10h | 2014-05-07 11:00 | 2014-05-09 13:00 | 51, 50 | 52.5d | 0d |  | Héctor Pablos López | 10h |
| 53 | 4.4 | Auditoría |  | 5h | 2014-05-09 15:00 | 2014-05-12 10:00 | 52 | 52.5d | 0d |  | Héctor Pablos López | 5h |
| 54 | 4.5 | Artefacto: Código fuente | milestone | 0h | 2014-05-12 10:00 | 2014-05-12 10:00 | 53 | 52.5d | 0d |  |  |  |

Notes:
- 27: Descripción: Desarrollo de los casos de uso del sistema
- 28: Descripción: Elaboración de la matriz de trazabilidad que relacion requisitos y casos de uso
- 29: Descripción: Realización y documentación del modelo de dominio
- 30: Descripción: Realización y documentación de los diagramas de secuencia
- 31: Descripción: Supervisión y aprobación del análisis del proyecto
- 34: Descripción: Elaboración de la documentación referente al diseño de la aplicación
- 36: Descripción: Identificación y búsqueda de información acerca de la tecnología necesaria para el desarrollo del proyecto
- 37: Descripción: Identificación y documentación de las interfaces necesarias
- 38: Descripción: Realización de los diagramas correspondientes a la descripción de la arquitectura (diagrama de despliegue, diagrama de componentes y diagrama de capas)
- 40: Descripción: Identificación y descripción de los susbsistemas que forman el sistema junto con la elaboración del diagrama correspondiente
- 41: Descripción: Realización de la ilustración que muestre la topología del sistema
- 42: Descripción: Descripción de la tecnología que se utilizará para manejar la persistencia de la aplicación
- 43: Descripción: Elaboración del diagrama que muestra la vista lógica del sistema
- 44: Descripción: Realización de los casos de uso de diseño a partir de los casos de uso obtenidos en el análisis
- 45: Descripción: Elaboración de los diagramas de secuencia de diseño en caso de que sea necesario
- 46: Descripción: Elaboración del modelo de dominio de diseño en caso de que sea necesario
- 47: Descripción: Supervisión y aprobación del diseño del proyecto
- 50: Descripción: Elaboración de los módulos
- 51: Descripción: Pruebas realizadas sobre los módulos en desarrollo
- 52: Descripción: Integración de todos los módulos entregados por los diferentes programadores
- 53: Descripción: Supervisión y aprobación de los módulos implementados

| ID | WBS | Task | Type | Duration | Start | Finish | Predecessors | Total slack | Free slack | Constraint | Resources | Work |
| --- | --- | --- | --- | --- | --- | --- | --- | --- | --- | --- | --- | --- |
| 55 | 5 | **Pruebas** |  | 73d | 2014-04-11 15:00 | 2014-05-23 17:00 |  | 52.5d | 0d |  |  | 91h |
| 56 | 5.1 | Desarrollo del plan de pruebas de caja blanca |  | 3h | 2014-04-11 15:00 | 2014-04-11 18:00 | 46 | 104d | 49d |  | Héctor Pablos López | 3h |
| 57 | 5.2 | Desarrollo del plan de pruebas de caja negra |  | 3h | 2014-04-11 15:00 | 2014-04-11 18:00 | 46 | 101.5d | 49d |  | Héctor Pablos López | 3h |
| 58 | 5.3 | **Pruebas de caja blanca en módulos** |  | 10d | 2014-05-12 10:00 | 2014-05-16 16:00 |  | 55d | 0d |  |  | 20h |
| 59 | 5.3.1 | Realización de pruebas de caja blanca sobre los módulos |  | 10h | 2014-05-12 10:00 | 2014-05-14 12:00 | 56, 54 | 55d | 0d |  | Héctor Pablos López | 10h |
| 60 | 5.3.2 | Identificar anomalías |  | 3h | 2014-05-14 12:00 | 2014-05-14 17:00 | 59 | 55d | 0d |  | Héctor Pablos López | 3h |
| 61 | 5.3.3 | Revisar y modificar el código |  | 7h | 2014-05-14 17:00 | 2014-05-16 16:00 | 60 | 55d |  |  | Héctor Pablos López | 7h |
| 62 | 5.4 | **Pruebas de caja negra en módulos** |  | 10d | 2014-05-12 10:00 | 2014-05-16 16:00 |  | 52.5d | 0d |  |  | 20h |
| 63 | 5.4.1 | Realización de pruebas de caja negra sobre los módulos |  | 10h | 2014-05-12 10:00 | 2014-05-14 12:00 | 54, 57 | 52.5d | 0d |  | Héctor Pablos López | 10h |
| 64 | 5.4.2 | Identificar anomalías |  | 3h | 2014-05-14 12:00 | 2014-05-14 17:00 | 63 | 52.5d | 0d |  | Héctor Pablos López | 3h |
| 65 | 5.4.3 | Revisar y modificar el código |  | 7h | 2014-05-14 17:00 | 2014-05-16 16:00 | 64 | 52.5d |  |  | Héctor Pablos López | 7h |
| 66 | 5.5 | **Pruebas de caja blanca en el programa completo** |  | 10d | 2014-05-16 16:00 | 2014-05-23 10:00 |  | 55d |  |  |  | 20h |
| 67 | 5.5.1 | Realización de pruebas de caja blanca sobre el programa completo |  | 10h | 2014-05-16 16:00 | 2014-05-19 18:00 | 58 | 55d | 0d |  | Héctor Pablos López | 10h |
| 68 | 5.5.2 | Identificar anomalías |  | 3h | 2014-05-19 18:00 | 2014-05-21 11:00 | 67 | 55d | 0d |  | Héctor Pablos López | 3h |
| 69 | 5.5.3 | Revisar y modificar el código |  | 7h | 2014-05-21 11:00 | 2014-05-23 10:00 | 68 | 55d |  |  | Héctor Pablos López | 7h |
| 70 | 5.6 | **Pruebas de caja negra en el programa completo** |  | 10d | 2014-05-16 16:00 | 2014-05-23 10:00 |  | 52.5d |  |  |  | 20h |
| 71 | 5.6.1 | Realización de pruebas de caja negra sobre el programa completo |  | 10h | 2014-05-16 16:00 | 2014-05-19 18:00 | 62 | 52.5d | 0d |  | Héctor Pablos López | 10h |
| 72 | 5.6.2 | Identificar anomalías |  | 3h | 2014-05-19 18:00 | 2014-05-21 11:00 | 71 | 52.5d | 0d |  | Héctor Pablos López | 3h |
| 73 | 5.6.3 | Revisar y modificar el código |  | 7h | 2014-05-21 11:00 | 2014-05-23 10:00 | 72 | 52.5d | 0d |  | Héctor Pablos López | 7h |
| 74 | 5.7 | Auditoría |  | 5h | 2014-05-23 10:00 | 2014-05-23 17:00 | 73 | 52.5d | 0d |  | Héctor Pablos López | 5h |
| 75 | 5.8 | Artefacto: Documento de pruebas | milestone | 0h | 2014-05-23 17:00 | 2014-05-23 17:00 | 74 | 52.5d |  |  | Héctor Pablos López |  |
| 76 | 6 | **Documentación** |  | 27.5d | 2014-05-23 17:00 | 2014-06-09 16:00 |  | 52.5d | 0d |  |  | 50h |
| 77 | 6.1 | Documentar desarrollo del proyecto |  | 15h | 2014-05-23 17:00 | 2014-05-28 16:00 | 55 | 52.5d | 0d |  | Héctor Pablos López | 15h |
| 78 | 6.2 | Integración de la documentación |  | 5h | 2014-05-28 16:00 | 2014-05-30 11:00 | 77 | 62.5d | 0d |  | Héctor Pablos López | 5h |
| 79 | 6.3 | Revisión de la documentación |  | 5h | 2014-05-30 18:00 | 2014-06-02 13:00 | 78FS+5h | 62.5d | 10d |  | Héctor Pablos López | 5h |
| 80 | 6.4 | Manual de instalación |  | 10h | 2014-06-02 15:00 | 2014-06-04 17:00 | 55, 77FS+15h | 57.5d | 5d |  | Héctor Pablos López | 10h |
| 81 | 6.5 | Manual de usuario |  | 10h | 2014-06-04 17:00 | 2014-06-06 19:00 | 55, 77FS+25h | 52.5d | 0d |  | Héctor Pablos López | 10h |
| 82 | 6.6 | Presentación powerpoint |  | 5h | 2014-06-09 09:00 | 2014-06-09 16:00 | 81 | 52.5d |  |  | Héctor Pablos López | 5h |
| 83 | 6.7 | Auditoria |  | 5h | 2014-06-09 09:00 | 2014-06-09 16:00 | 79, 81, 80 | 52.5d | 0d |  |  |  |
| 84 | 6.8 | Entrega documentacion | milestone | 0h | 2014-06-09 16:00 | 2014-06-09 16:00 | 83 | 52.5d |  |  |  |  |
| 85 | 7 | Auditoría de todo el proyecto |  | 10h | 2014-06-09 16:00 | 2014-06-11 18:00 | 76 | 32.5d | 0d |  |  |  |
| 86 | 8 | Gestión de cambio |  | 5h | 2014-06-11 11:00 | 2014-06-11 18:00 | 2SS, 85FF | 52.5d |  |  |  |  |
| 87 | 9 | Entrega final | milestone | 0h | 2014-06-30 19:00 | 2014-06-30 19:00 | 85 | 20d |  | start no earlier than 2014-06-30 19:00 |  |  |
| 88 | 10 | Defensa ante el tribunal | milestone | 0h | 2014-07-11 19:00 | 2014-07-11 19:00 | 87 | 0d |  | start no earlier than 2014-07-11 19:00 |  |  |

Notes:
- 56: Descripción: Elaboración de la documentación donde se detalla el plan que se seguirá a la hora de realizar las pruebas de caja blanca
- 57: Descripción: Elaboración de la documentación donde se detalla el plan que se seguirá a la hora de realizar las pruebas de caja negra
- 60: Descripción: Identificación y análisis de los posibles resultados erróneos obtenidos en las pruebas
- 64: Descripción: Identificación y análisis de los posibles resultados erróneos obtenidos en las pruebas
- 68: Descripción: Identificación y análisis de los posibles resultados erróneos obtenidos en las pruebas
- 72: Descripción: Identificación y análisis de los posibles resultados erróneos obtenidos en las pruebas
- 77: Descripción: Elaboración de la documentación sobre el plan de desarrollo seguido a lo largo del proyecto y sus conclusiones
- 78: Descripción: Integración de toda la documentación obtenida en las diferentes fases del proyecto y de su desarrollo
- 79: Descripción: Revisión y aprobación de la documentación de todo el proyecto
- 80: Descripción: Documentación de los pasos necesarios para instalar la aplicación
- 81: Descripción: Elaboración del manual de usuario
- 82: Descripción: Elaboración de la presentación para la defensa
- 83: Descripción: Supervisión y aprobación de toda la documentación del proyecto junto con los manuales
- 85: Descripción: Supervisión y aprobación del proyecto
- 86: Descripción: Durante todo el desarrollo del proyecto, éste estará abierto al cambio, los cuales hay que registrar. Esta tarea es la encargada de representar estos posibles cambios
- 87: Descripción: Entrega de la documentación
- 88: Descripción: Defensa del proyecto ante el tribunal designado al efecto
